project acso "Accounting Software" "1.0" 2002-01-16-00:00-+0000 - 2002-05-17-16:00-+0000 {
  timezone "Europe/Paris"
  extend resource{
    text Phone "Phone"
  }
  scenario plan "Plan" {
    scenario delayed "Delayed" {
      active yes
    }
    active yes
  }
}

flags team

projectids acso

resource boss "Paul Henry Bullock"
resource dev "Developers" {
  resource dev1 "Paul Smith"
  resource dev2 "Sébastien Bono"
  resource dev3 "Klaus Müller"
}
resource misc "The Others" {
  resource test "Peter Murphy"
  resource doc "Dim Sung"
}

task AcSo "Accounting Software" {
  task spec "Specification" {
    depends AcSo.deliveries.start
    start 2002-01-16-08:00-+0000
    end 2002-01-24-14:00-+0000
    scheduling asap
    scheduled
    delayed:start 2002-01-21-08:00-+0000
    delayed:end 2002-01-29-14:00-+0000
    delayed:scheduling asap
  }
  task software "Software Development" {
    depends AcSo.spec
    task database "Database coupling" {
      start 2002-01-24-14:00-+0000
      end 2002-02-07-14:00-+0000
      scheduling asap
      scheduled
      delayed:start 2002-01-29-14:00-+0000
      delayed:end 2002-02-12-14:00-+0000
      delayed:scheduling asap
    }
    task gui "Graphical User Interface" {
      depends AcSo.software.database, AcSo.software.backend
      start 2002-02-28-14:00-+0000
      end 2002-03-28-13:00-+0000
      scheduling asap
      scheduled
      delayed:start 2002-03-05-14:00-+0000
      delayed:end 2002-04-08-11:00-+0000
      delayed:scheduling asap
    }
    task backend "Back-End Functions" {
      depends AcSo.software.database
      start 2002-02-07-14:00-+0000
      end 2002-02-28-14:00-+0000
      scheduling asap
      scheduled
      delayed:start 2002-02-12-14:00-+0000
      delayed:end 2002-03-05-14:00-+0000
      delayed:scheduling asap
    }
  }
  task test "Software testing" {
    task alpha "Alpha Test" {
      depends AcSo.software
      start 2002-03-28-13:00-+0000
      end 2002-04-03-10:00-+0000
      scheduling asap
      scheduled
      delayed:start 2002-04-08-11:00-+0000
      delayed:end 2002-04-11-09:00-+0000
      delayed:scheduling asap
    }
    task beta "Beta Test" {
      depends AcSo.test.alpha
      start 2002-04-03-10:00-+0000
      end 2002-04-18-13:00-+0000
      scheduling asap
      scheduled
      delayed:start 2002-04-11-09:00-+0000
      delayed:end 2002-04-26-12:00-+0000
      delayed:scheduling asap
    }
  }
  task manual "Manual" {
    depends AcSo.deliveries.start
    start 2002-01-16-08:00-+0000
    end 2002-02-26-11:00-+0000
    scheduling asap
    scheduled
    delayed:start 2002-01-21-08:00-+0000
    delayed:end 2002-03-01-11:00-+0000
    delayed:scheduling asap
  }
  task deliveries "Milestones" {
    task start "Project start" {
      start 2002-01-16-00:00-+0000
      scheduled
      delayed:start 2002-01-19-23:00-+0000
    }
    task prev "Technology Preview" {
      depends AcSo.software.backend
      start 2002-02-28-14:00-+0000
      scheduled
      delayed:start 2002-03-05-14:00-+0000
    }
    task beta "Beta version" {
      depends AcSo.test.alpha
      start 2002-04-03-10:00-+0000
      scheduled
      delayed:start 2002-04-11-09:00-+0000
    }
    task done "Ship Product to Customer" {
      depends AcSo.test.beta, AcSo.manual
      start 2002-04-18-13:00-+0000
      scheduled
      delayed:start 2002-04-26-12:00-+0000
    }
  }
}
supplement task AcSo {
  priority 500
  projectid acso
  responsible boss
}
supplement task AcSo.spec {
  booking dev1 2002-01-16-08:00-+0000 + 8.0h,
          2002-01-17-08:00-+0000 + 8.0h,
          2002-01-18-08:00-+0000 + 8.0h,
          2002-01-21-08:00-+0000 + 8.0h,
          2002-01-22-08:00-+0000 + 8.0h,
          2002-01-23-08:00-+0000 + 8.0h,
          2002-01-24-08:00-+0000 + 6.0h { overtime 2 }
  booking dev2 2002-01-16-08:00-+0000 + 8.0h,
          2002-01-17-08:00-+0000 + 8.0h,
          2002-01-18-08:00-+0000 + 8.0h,
          2002-01-21-08:00-+0000 + 8.0h,
          2002-01-22-08:00-+0000 + 8.0h,
          2002-01-23-08:00-+0000 + 8.0h,
          2002-01-24-08:00-+0000 + 5.0h { overtime 2 }
  booking dev3 2002-01-16-08:00-+0000 + 8.0h,
          2002-01-17-08:00-+0000 + 8.0h,
          2002-01-18-08:00-+0000 + 8.0h,
          2002-01-21-08:00-+0000 + 8.0h,
          2002-01-22-08:00-+0000 + 8.0h,
          2002-01-23-08:00-+0000 + 8.0h,
          2002-01-24-08:00-+0000 + 5.0h { overtime 2 }
  delayed:booking dev1 2002-01-21-08:00-+0000 + 8.0h,
                  2002-01-22-08:00-+0000 + 8.0h,
                  2002-01-23-08:00-+0000 + 8.0h,
                  2002-01-24-08:00-+0000 + 8.0h,
                  2002-01-25-08:00-+0000 + 8.0h,
                  2002-01-28-08:00-+0000 + 8.0h,
                  2002-01-29-08:00-+0000 + 6.0h { overtime 2 }
  delayed:booking dev2 2002-01-21-08:00-+0000 + 8.0h,
                  2002-01-22-08:00-+0000 + 8.0h,
                  2002-01-23-08:00-+0000 + 8.0h,
                  2002-01-24-08:00-+0000 + 8.0h,
                  2002-01-25-08:00-+0000 + 8.0h,
                  2002-01-28-08:00-+0000 + 8.0h,
                  2002-01-29-08:00-+0000 + 5.0h { overtime 2 }
  delayed:booking dev3 2002-01-21-08:00-+0000 + 8.0h,
                  2002-01-22-08:00-+0000 + 8.0h,
                  2002-01-23-08:00-+0000 + 8.0h,
                  2002-01-24-08:00-+0000 + 8.0h,
                  2002-01-25-08:00-+0000 + 8.0h,
                  2002-01-28-08:00-+0000 + 8.0h,
                  2002-01-29-08:00-+0000 + 5.0h { overtime 2 }
  priority 500
  projectid acso
  responsible boss
}
supplement task AcSo.software {
  priority 1000
  projectid acso
  responsible boss, dev1
}
supplement task AcSo.software.database {
  booking dev1 2002-01-24-14:00-+0000 + 2.0h,
          2002-01-25-08:00-+0000 + 8.0h,
          2002-01-28-08:00-+0000 + 8.0h,
          2002-01-29-08:00-+0000 + 8.0h,
          2002-01-30-08:00-+0000 + 8.0h,
          2002-01-31-08:00-+0000 + 8.0h,
          2002-02-01-08:00-+0000 + 8.0h,
          2002-02-04-08:00-+0000 + 8.0h,
          2002-02-05-08:00-+0000 + 8.0h,
          2002-02-06-08:00-+0000 + 8.0h,
          2002-02-07-08:00-+0000 + 6.0h { overtime 2 }
  booking dev2 2002-01-24-14:00-+0000 + 2.0h,
          2002-01-25-08:00-+0000 + 8.0h,
          2002-01-28-08:00-+0000 + 8.0h,
          2002-01-29-08:00-+0000 + 8.0h,
          2002-01-30-08:00-+0000 + 8.0h,
          2002-01-31-08:00-+0000 + 8.0h,
          2002-02-01-08:00-+0000 + 8.0h,
          2002-02-04-08:00-+0000 + 8.0h,
          2002-02-05-08:00-+0000 + 8.0h,
          2002-02-06-08:00-+0000 + 8.0h,
          2002-02-07-08:00-+0000 + 6.0h { overtime 2 }
  delayed:booking dev1 2002-01-29-14:00-+0000 + 2.0h,
                  2002-01-30-08:00-+0000 + 8.0h,
                  2002-01-31-08:00-+0000 + 8.0h,
                  2002-02-01-08:00-+0000 + 8.0h,
                  2002-02-04-08:00-+0000 + 8.0h,
                  2002-02-05-08:00-+0000 + 8.0h,
                  2002-02-06-08:00-+0000 + 8.0h,
                  2002-02-07-08:00-+0000 + 8.0h,
                  2002-02-08-08:00-+0000 + 8.0h,
                  2002-02-11-08:00-+0000 + 8.0h,
                  2002-02-12-08:00-+0000 + 6.0h { overtime 2 }
  delayed:booking dev2 2002-01-29-14:00-+0000 + 2.0h,
                  2002-01-30-08:00-+0000 + 8.0h,
                  2002-01-31-08:00-+0000 + 8.0h,
                  2002-02-01-08:00-+0000 + 8.0h,
                  2002-02-04-08:00-+0000 + 8.0h,
                  2002-02-05-08:00-+0000 + 8.0h,
                  2002-02-06-08:00-+0000 + 8.0h,
                  2002-02-07-08:00-+0000 + 8.0h,
                  2002-02-08-08:00-+0000 + 8.0h,
                  2002-02-11-08:00-+0000 + 8.0h,
                  2002-02-12-08:00-+0000 + 6.0h { overtime 2 }
  priority 1000
  projectid acso
  responsible boss, dev1
}
supplement task AcSo.software.gui {
  booking dev2 2002-02-28-14:00-+0000 + 2.0h,
          2002-03-01-08:00-+0000 + 6.0h,
          2002-03-04-08:00-+0000 + 6.0h,
          2002-03-05-08:00-+0000 + 6.0h,
          2002-03-06-08:00-+0000 + 6.0h,
          2002-03-07-08:00-+0000 + 6.0h,
          2002-03-08-08:00-+0000 + 6.0h,
          2002-03-11-08:00-+0000 + 6.0h,
          2002-03-12-08:00-+0000 + 6.0h,
          2002-03-13-08:00-+0000 + 6.0h,
          2002-03-14-08:00-+0000 + 6.0h,
          2002-03-15-08:00-+0000 + 6.0h,
          2002-03-18-08:00-+0000 + 6.0h,
          2002-03-19-08:00-+0000 + 6.0h,
          2002-03-20-08:00-+0000 + 6.0h,
          2002-03-21-08:00-+0000 + 6.0h,
          2002-03-22-08:00-+0000 + 6.0h,
          2002-03-25-08:00-+0000 + 6.0h,
          2002-03-26-08:00-+0000 + 6.0h,
          2002-03-27-08:00-+0000 + 6.0h,
          2002-03-28-08:00-+0000 + 5.0h { overtime 2 }
  booking dev3 2002-02-28-14:00-+0000 + 2.0h,
          2002-03-01-08:00-+0000 + 8.0h,
          2002-03-04-08:00-+0000 + 8.0h,
          2002-03-05-08:00-+0000 + 8.0h,
          2002-03-06-08:00-+0000 + 8.0h,
          2002-03-07-08:00-+0000 + 8.0h,
          2002-03-08-08:00-+0000 + 8.0h,
          2002-03-11-08:00-+0000 + 8.0h,
          2002-03-12-08:00-+0000 + 8.0h,
          2002-03-13-08:00-+0000 + 8.0h,
          2002-03-14-08:00-+0000 + 8.0h,
          2002-03-15-08:00-+0000 + 8.0h,
          2002-03-18-08:00-+0000 + 8.0h,
          2002-03-19-08:00-+0000 + 8.0h,
          2002-03-20-08:00-+0000 + 8.0h,
          2002-03-21-08:00-+0000 + 8.0h,
          2002-03-22-08:00-+0000 + 8.0h,
          2002-03-25-08:00-+0000 + 8.0h,
          2002-03-26-08:00-+0000 + 8.0h,
          2002-03-27-08:00-+0000 + 8.0h,
          2002-03-28-08:00-+0000 + 5.0h { overtime 2 }
  delayed:booking dev2 2002-03-05-14:00-+0000 + 2.0h,
                  2002-03-06-08:00-+0000 + 6.0h,
                  2002-03-07-08:00-+0000 + 6.0h,
                  2002-03-08-08:00-+0000 + 6.0h,
                  2002-03-11-08:00-+0000 + 6.0h,
                  2002-03-12-08:00-+0000 + 6.0h,
                  2002-03-13-08:00-+0000 + 6.0h,
                  2002-03-14-08:00-+0000 + 6.0h,
                  2002-03-15-08:00-+0000 + 6.0h,
                  2002-03-18-08:00-+0000 + 6.0h,
                  2002-03-19-08:00-+0000 + 6.0h,
                  2002-03-20-08:00-+0000 + 6.0h,
                  2002-03-21-08:00-+0000 + 6.0h,
                  2002-03-22-08:00-+0000 + 6.0h,
                  2002-03-25-08:00-+0000 + 6.0h,
                  2002-03-26-08:00-+0000 + 6.0h,
                  2002-03-27-08:00-+0000 + 6.0h,
                  2002-03-28-08:00-+0000 + 6.0h,
                  2002-04-01-07:00-+0000 + 6.0h,
                  2002-04-02-07:00-+0000 + 6.0h,
                  2002-04-03-07:00-+0000 + 6.0h,
                  2002-04-04-07:00-+0000 + 6.0h,
                  2002-04-05-07:00-+0000 + 6.0h,
                  2002-04-08-07:00-+0000 + 4.0h { overtime 2 }
  delayed:booking dev3 2002-03-05-14:00-+0000 + 2.0h,
                  2002-03-06-08:00-+0000 + 8.0h,
                  2002-03-07-08:00-+0000 + 8.0h,
                  2002-03-08-08:00-+0000 + 8.0h,
                  2002-03-11-08:00-+0000 + 8.0h,
                  2002-03-12-08:00-+0000 + 8.0h,
                  2002-03-13-08:00-+0000 + 8.0h,
                  2002-03-14-08:00-+0000 + 8.0h,
                  2002-03-15-08:00-+0000 + 8.0h,
                  2002-03-18-08:00-+0000 + 8.0h,
                  2002-03-19-08:00-+0000 + 8.0h,
                  2002-03-20-08:00-+0000 + 8.0h,
                  2002-03-21-08:00-+0000 + 8.0h,
                  2002-03-22-08:00-+0000 + 8.0h,
                  2002-03-25-08:00-+0000 + 8.0h,
                  2002-03-26-08:00-+0000 + 8.0h,
                  2002-03-27-08:00-+0000 + 8.0h,
                  2002-03-28-08:00-+0000 + 8.0h,
                  2002-04-01-07:00-+0000 + 8.0h,
                  2002-04-02-07:00-+0000 + 8.0h,
                  2002-04-03-07:00-+0000 + 8.0h,
                  2002-04-04-07:00-+0000 + 8.0h,
                  2002-04-05-07:00-+0000 + 8.0h,
                  2002-04-08-07:00-+0000 + 4.0h { overtime 2 }
  priority 1000
  projectid acso
  responsible boss, dev1
}
supplement task AcSo.software.backend {
  booking dev1 2002-02-07-14:00-+0000 + 2.0h,
          2002-02-08-08:00-+0000 + 8.0h,
          2002-02-11-08:00-+0000 + 8.0h,
          2002-02-12-08:00-+0000 + 8.0h,
          2002-02-13-08:00-+0000 + 8.0h,
          2002-02-14-08:00-+0000 + 8.0h,
          2002-02-15-08:00-+0000 + 8.0h,
          2002-02-18-08:00-+0000 + 8.0h,
          2002-02-19-08:00-+0000 + 8.0h,
          2002-02-20-08:00-+0000 + 8.0h,
          2002-02-21-08:00-+0000 + 8.0h,
          2002-02-22-08:00-+0000 + 8.0h,
          2002-02-25-08:00-+0000 + 8.0h,
          2002-02-26-08:00-+0000 + 8.0h,
          2002-02-27-08:00-+0000 + 8.0h,
          2002-02-28-08:00-+0000 + 6.0h { overtime 2 }
  booking dev2 2002-02-07-14:00-+0000 + 2.0h,
          2002-02-08-08:00-+0000 + 8.0h,
          2002-02-11-08:00-+0000 + 8.0h,
          2002-02-12-08:00-+0000 + 8.0h,
          2002-02-13-08:00-+0000 + 8.0h,
          2002-02-14-08:00-+0000 + 8.0h,
          2002-02-15-08:00-+0000 + 8.0h,
          2002-02-18-08:00-+0000 + 8.0h,
          2002-02-19-08:00-+0000 + 8.0h,
          2002-02-20-08:00-+0000 + 8.0h,
          2002-02-21-08:00-+0000 + 8.0h,
          2002-02-22-08:00-+0000 + 8.0h,
          2002-02-25-08:00-+0000 + 8.0h,
          2002-02-26-08:00-+0000 + 8.0h,
          2002-02-27-08:00-+0000 + 8.0h,
          2002-02-28-08:00-+0000 + 6.0h { overtime 2 }
  delayed:booking dev1 2002-02-12-14:00-+0000 + 2.0h,
                  2002-02-13-08:00-+0000 + 8.0h,
                  2002-02-14-08:00-+0000 + 8.0h,
                  2002-02-15-08:00-+0000 + 8.0h,
                  2002-02-18-08:00-+0000 + 8.0h,
                  2002-02-19-08:00-+0000 + 8.0h,
                  2002-02-20-08:00-+0000 + 8.0h,
                  2002-02-21-08:00-+0000 + 8.0h,
                  2002-02-22-08:00-+0000 + 8.0h,
                  2002-02-25-08:00-+0000 + 8.0h,
                  2002-02-26-08:00-+0000 + 8.0h,
                  2002-02-27-08:00-+0000 + 8.0h,
                  2002-02-28-08:00-+0000 + 8.0h,
                  2002-03-01-08:00-+0000 + 8.0h,
                  2002-03-04-08:00-+0000 + 8.0h,
                  2002-03-05-08:00-+0000 + 6.0h { overtime 2 }
  delayed:booking dev2 2002-02-12-14:00-+0000 + 2.0h,
                  2002-02-13-08:00-+0000 + 8.0h,
                  2002-02-14-08:00-+0000 + 8.0h,
                  2002-02-15-08:00-+0000 + 8.0h,
                  2002-02-18-08:00-+0000 + 8.0h,
                  2002-02-19-08:00-+0000 + 8.0h,
                  2002-02-20-08:00-+0000 + 8.0h,
                  2002-02-21-08:00-+0000 + 8.0h,
                  2002-02-22-08:00-+0000 + 8.0h,
                  2002-02-25-08:00-+0000 + 8.0h,
                  2002-02-26-08:00-+0000 + 8.0h,
                  2002-02-27-08:00-+0000 + 8.0h,
                  2002-02-28-08:00-+0000 + 8.0h,
                  2002-03-01-08:00-+0000 + 8.0h,
                  2002-03-04-08:00-+0000 + 8.0h,
                  2002-03-05-08:00-+0000 + 6.0h { overtime 2 }
  complete 95
  priority 1000
  projectid acso
  responsible boss, dev1
}
supplement task AcSo.test {
  priority 500
  projectid acso
  responsible boss
}
supplement task AcSo.test.alpha {
  booking dev2 2002-03-28-13:00-+0000 + 3.0h,
          2002-04-01-07:00-+0000 + 8.0h,
          2002-04-02-07:00-+0000 + 8.0h,
          2002-04-03-07:00-+0000 + 3.0h { overtime 2 }
  booking test 2002-03-28-13:00-+0000 + 3.0h,
          2002-04-01-07:00-+0000 + 6.0h,
          2002-04-02-07:00-+0000 + 6.0h,
          2002-04-03-07:00-+0000 + 3.0h { overtime 2 }
  delayed:booking dev2 2002-04-08-11:00-+0000 + 4.0h,
                  2002-04-09-07:00-+0000 + 8.0h,
                  2002-04-10-07:00-+0000 + 8.0h,
                  2002-04-11-07:00-+0000 + 2.0h { overtime 2 }
  delayed:booking test 2002-04-08-11:00-+0000 + 4.0h,
                  2002-04-09-07:00-+0000 + 6.0h,
                  2002-04-10-07:00-+0000 + 6.0h,
                  2002-04-11-07:00-+0000 + 2.0h { overtime 2 }
  note "Hopefully most bugs will be found and fixed here."
  priority 500
  projectid acso
  responsible boss
}
supplement task AcSo.test.beta {
  booking dev1 2002-04-03-10:00-+0000 + 5.0h,
          2002-04-04-07:00-+0000 + 8.0h,
          2002-04-05-07:00-+0000 + 8.0h,
          2002-04-08-07:00-+0000 + 8.0h,
          2002-04-09-07:00-+0000 + 8.0h,
          2002-04-10-07:00-+0000 + 8.0h,
          2002-04-11-07:00-+0000 + 8.0h,
          2002-04-12-07:00-+0000 + 8.0h,
          2002-04-15-07:00-+0000 + 8.0h,
          2002-04-16-07:00-+0000 + 8.0h,
          2002-04-17-07:00-+0000 + 8.0h,
          2002-04-18-07:00-+0000 + 6.0h { overtime 2 }
  booking test 2002-04-03-10:00-+0000 + 3.0h,
          2002-04-04-07:00-+0000 + 6.0h,
          2002-04-05-07:00-+0000 + 6.0h,
          2002-04-08-07:00-+0000 + 6.0h,
          2002-04-09-07:00-+0000 + 6.0h,
          2002-04-10-07:00-+0000 + 6.0h,
          2002-04-11-07:00-+0000 + 6.0h,
          2002-04-12-07:00-+0000 + 6.0h,
          2002-04-15-07:00-+0000 + 6.0h,
          2002-04-16-07:00-+0000 + 6.0h,
          2002-04-17-07:00-+0000 + 6.0h,
          2002-04-18-07:00-+0000 + 6.0h { overtime 2 }
  delayed:booking dev1 2002-04-11-09:00-+0000 + 6.0h,
                  2002-04-12-07:00-+0000 + 8.0h,
                  2002-04-15-07:00-+0000 + 8.0h,
                  2002-04-16-07:00-+0000 + 8.0h,
                  2002-04-17-07:00-+0000 + 8.0h,
                  2002-04-18-07:00-+0000 + 8.0h,
                  2002-04-19-07:00-+0000 + 8.0h,
                  2002-04-22-07:00-+0000 + 8.0h,
                  2002-04-23-07:00-+0000 + 8.0h,
                  2002-04-24-07:00-+0000 + 8.0h,
                  2002-04-25-07:00-+0000 + 8.0h,
                  2002-04-26-07:00-+0000 + 5.0h { overtime 2 }
  delayed:booking test 2002-04-11-09:00-+0000 + 4.0h,
                  2002-04-12-07:00-+0000 + 6.0h,
                  2002-04-15-07:00-+0000 + 6.0h,
                  2002-04-16-07:00-+0000 + 6.0h,
                  2002-04-17-07:00-+0000 + 6.0h,
                  2002-04-18-07:00-+0000 + 6.0h,
                  2002-04-19-07:00-+0000 + 6.0h,
                  2002-04-22-07:00-+0000 + 6.0h,
                  2002-04-23-07:00-+0000 + 6.0h,
                  2002-04-24-07:00-+0000 + 6.0h,
                  2002-04-25-07:00-+0000 + 6.0h,
                  2002-04-26-07:00-+0000 + 5.0h { overtime 2 }
  priority 500
  projectid acso
  responsible boss
}
supplement task AcSo.manual {
  booking dev3 2002-01-24-13:00-+0000 + 3.0h,
          2002-01-25-08:00-+0000 + 8.0h,
          2002-01-28-08:00-+0000 + 8.0h,
          2002-01-29-08:00-+0000 + 8.0h,
          2002-01-30-08:00-+0000 + 8.0h,
          2002-01-31-08:00-+0000 + 8.0h,
          2002-02-05-08:00-+0000 + 8.0h,
          2002-02-06-08:00-+0000 + 8.0h,
          2002-02-07-08:00-+0000 + 8.0h,
          2002-02-08-08:00-+0000 + 8.0h,
          2002-02-11-08:00-+0000 + 8.0h,
          2002-02-12-08:00-+0000 + 8.0h,
          2002-02-13-08:00-+0000 + 8.0h,
          2002-02-14-08:00-+0000 + 8.0h,
          2002-02-15-08:00-+0000 + 8.0h,
          2002-02-18-08:00-+0000 + 8.0h,
          2002-02-19-08:00-+0000 + 8.0h,
          2002-02-20-08:00-+0000 + 8.0h,
          2002-02-21-08:00-+0000 + 8.0h,
          2002-02-22-08:00-+0000 + 8.0h,
          2002-02-25-08:00-+0000 + 8.0h,
          2002-02-26-08:00-+0000 + 2.0h { overtime 2 }
  booking doc 2002-01-16-08:00-+0000 + 8.0h,
          2002-01-17-08:00-+0000 + 8.0h,
          2002-01-18-08:00-+0000 + 8.0h,
          2002-01-21-08:00-+0000 + 8.0h,
          2002-01-22-08:00-+0000 + 8.0h,
          2002-01-23-08:00-+0000 + 8.0h,
          2002-01-24-08:00-+0000 + 8.0h,
          2002-01-25-08:00-+0000 + 8.0h,
          2002-01-28-08:00-+0000 + 8.0h,
          2002-01-29-08:00-+0000 + 8.0h,
          2002-01-30-08:00-+0000 + 8.0h,
          2002-01-31-08:00-+0000 + 8.0h,
          2002-02-01-08:00-+0000 + 8.0h,
          2002-02-04-08:00-+0000 + 8.0h,
          2002-02-05-08:00-+0000 + 8.0h,
          2002-02-06-08:00-+0000 + 8.0h,
          2002-02-07-08:00-+0000 + 8.0h,
          2002-02-08-08:00-+0000 + 8.0h,
          2002-02-11-08:00-+0000 + 8.0h,
          2002-02-12-08:00-+0000 + 8.0h,
          2002-02-13-08:00-+0000 + 8.0h,
          2002-02-14-08:00-+0000 + 8.0h,
          2002-02-15-08:00-+0000 + 8.0h,
          2002-02-18-08:00-+0000 + 8.0h,
          2002-02-19-08:00-+0000 + 8.0h,
          2002-02-20-08:00-+0000 + 8.0h,
          2002-02-21-08:00-+0000 + 8.0h,
          2002-02-22-08:00-+0000 + 8.0h,
          2002-02-25-08:00-+0000 + 8.0h,
          2002-02-26-08:00-+0000 + 3.0h { overtime 2 }
  delayed:booking dev3 2002-01-29-13:00-+0000 + 3.0h,
                  2002-01-30-08:00-+0000 + 8.0h,
                  2002-01-31-08:00-+0000 + 8.0h,
                  2002-02-05-08:00-+0000 + 8.0h,
                  2002-02-06-08:00-+0000 + 8.0h,
                  2002-02-07-08:00-+0000 + 8.0h,
                  2002-02-08-08:00-+0000 + 8.0h,
                  2002-02-11-08:00-+0000 + 8.0h,
                  2002-02-12-08:00-+0000 + 8.0h,
                  2002-02-13-08:00-+0000 + 8.0h,
                  2002-02-14-08:00-+0000 + 8.0h,
                  2002-02-15-08:00-+0000 + 8.0h,
                  2002-02-18-08:00-+0000 + 8.0h,
                  2002-02-19-08:00-+0000 + 8.0h,
                  2002-02-20-08:00-+0000 + 8.0h,
                  2002-02-21-08:00-+0000 + 8.0h,
                  2002-02-22-08:00-+0000 + 8.0h,
                  2002-02-25-08:00-+0000 + 8.0h,
                  2002-02-26-08:00-+0000 + 8.0h,
                  2002-02-27-08:00-+0000 + 8.0h,
                  2002-02-28-08:00-+0000 + 8.0h,
                  2002-03-01-08:00-+0000 + 2.0h { overtime 2 }
  delayed:booking doc 2002-01-21-08:00-+0000 + 8.0h,
                  2002-01-22-08:00-+0000 + 8.0h,
                  2002-01-23-08:00-+0000 + 8.0h,
                  2002-01-24-08:00-+0000 + 8.0h,
                  2002-01-25-08:00-+0000 + 8.0h,
                  2002-01-28-08:00-+0000 + 8.0h,
                  2002-01-29-08:00-+0000 + 8.0h,
                  2002-01-30-08:00-+0000 + 8.0h,
                  2002-01-31-08:00-+0000 + 8.0h,
                  2002-02-01-08:00-+0000 + 8.0h,
                  2002-02-04-08:00-+0000 + 8.0h,
                  2002-02-05-08:00-+0000 + 8.0h,
                  2002-02-06-08:00-+0000 + 8.0h,
                  2002-02-07-08:00-+0000 + 8.0h,
                  2002-02-08-08:00-+0000 + 8.0h,
                  2002-02-11-08:00-+0000 + 8.0h,
                  2002-02-12-08:00-+0000 + 8.0h,
                  2002-02-13-08:00-+0000 + 8.0h,
                  2002-02-14-08:00-+0000 + 8.0h,
                  2002-02-15-08:00-+0000 + 8.0h,
                  2002-02-18-08:00-+0000 + 8.0h,
                  2002-02-19-08:00-+0000 + 8.0h,
                  2002-02-20-08:00-+0000 + 8.0h,
                  2002-02-21-08:00-+0000 + 8.0h,
                  2002-02-22-08:00-+0000 + 8.0h,
                  2002-02-25-08:00-+0000 + 8.0h,
                  2002-02-26-08:00-+0000 + 8.0h,
                  2002-02-27-08:00-+0000 + 8.0h,
                  2002-02-28-08:00-+0000 + 8.0h,
                  2002-03-01-08:00-+0000 + 3.0h { overtime 2 }
  priority 500
  projectid acso
  responsible boss
}
supplement task AcSo.deliveries {
  priority 500
  projectid acso
  responsible boss
}
supplement task AcSo.deliveries.start {
  priority 500
  projectid acso
  responsible boss
}
supplement task AcSo.deliveries.prev {
  note "All '''major''' features should be usable."
  priority 500
  projectid acso
  responsible boss
}
supplement task AcSo.deliveries.beta {
  note "Fully functional, may contain bugs."
  priority 500
  projectid acso
  responsible boss
}
supplement task AcSo.deliveries.done {
  note "All priority 1 and 2 bugs must be fixed."
  priority 500
  projectid acso
  responsible boss
}
supplement resource boss {
  Phone "x100"
  workinghours sun off
               workinghours mon 9:00 - 17:00
               workinghours tue 9:00 - 17:00
               workinghours wed 9:00 - 17:00
               workinghours thu 9:00 - 17:00
               workinghours fri 9:00 - 17:00
               workinghours sat off
}
supplement resource dev {
  flags team
  workinghours sun off
               workinghours mon 9:00 - 17:00
               workinghours tue 9:00 - 17:00
               workinghours wed 9:00 - 17:00
               workinghours thu 9:00 - 17:00
               workinghours fri 9:00 - 17:00
               workinghours sat off
}
supplement resource dev1 {
  Phone "x362"
  workinghours sun off
               workinghours mon 9:00 - 17:00
               workinghours tue 9:00 - 17:00
               workinghours wed 9:00 - 17:00
               workinghours thu 9:00 - 17:00
               workinghours fri 9:00 - 17:00
               workinghours sat off
}
supplement resource dev2 {
  Phone "x234"
  workinghours sun off
               workinghours mon 9:00 - 17:00
               workinghours tue 9:00 - 17:00
               workinghours wed 9:00 - 17:00
               workinghours thu 9:00 - 17:00
               workinghours fri 9:00 - 17:00
               workinghours sat off
}
supplement resource dev3 {
  Phone "x490"
  workinghours sun off
               workinghours mon 9:00 - 17:00
               workinghours tue 9:00 - 17:00
               workinghours wed 9:00 - 17:00
               workinghours thu 9:00 - 17:00
               workinghours fri 9:00 - 17:00
               workinghours sat off
}
supplement resource misc {
  flags team
  workinghours sun off
               workinghours mon 9:00 - 17:00
               workinghours tue 9:00 - 17:00
               workinghours wed 9:00 - 17:00
               workinghours thu 9:00 - 17:00
               workinghours fri 9:00 - 17:00
               workinghours sat off
}
supplement resource test {
  Phone "x666"
  workinghours sun off
               workinghours mon 9:00 - 17:00
               workinghours tue 9:00 - 17:00
               workinghours wed 9:00 - 17:00
               workinghours thu 9:00 - 17:00
               workinghours fri 9:00 - 17:00
               workinghours sat off
}
supplement resource doc {
  Phone "x482"
  workinghours sun off
               workinghours mon 9:00 - 17:00
               workinghours tue 9:00 - 17:00
               workinghours wed 9:00 - 17:00
               workinghours thu 9:00 - 17:00
               workinghours fri 9:00 - 17:00
               workinghours sat off
}
